# Enter Project

Schedule from MS Project, 2024-01-02 to 2026-01-29, 7.5 hours a day.

## Calendars

- Standard: Mon-Fri 08:00-12:00, 13:00-16:30; Sat-Sun off. Exceptions (off unless hours are given): 2021-01-01 to 2040-01-01 (New Year's Day, recurring), 2022-01-17 to 2041-01-21 (MLK Day, recurring), 2022-02-21 to 2041-02-18 (Presidents Day, recurring), 2022-05-30 to 2041-05-27 (Memorial Day, recurring), 2022-07-04 to 2041-07-04 (Independence Day, recurring), 2022-09-05 to 2041-09-02 (Labor Day, recurring), 2022-11-11 to 2041-11-08 (Veterans Day, recurring), 2022-11-24 to 2041-11-28 (Thanksgiving, recurring), 2022-11-25 to 2041-11-22 (Day after Thanksgiving, recurring), 2022-12-24 to 2041-12-24 (Christmas Eve, recurring), 2022-12-25 to 2041-12-22 (Christmas Day, recurring), 2022-12-31 to 2041-12-31 (New Year's Eve, recurring), 2023-06-19 to 2041-06-19 (Juneteenth, recurring), 2024-03-29 (Good Friday (2024)), 2025-04-18 (Good Friday (2025)).

## Schedule

| ID | WBS | Task | Duration | Start | Finish | Predecessors | Total slack | Free slack |
| --- | --- | --- | --- | --- | --- | --- | --- | --- |
| 1 | 1 | **STAGE 0 - PLANNING** | 125d? | 2024-01-02 | 2024-07-01 |  | 67d |  |
| 2 | 1.1 | **0SD1 Initiate Concept Report and Request Funding** | 35d | 2024-01-02 | 2024-02-21 |  | 67d |  |
| 3 | 1.1.1 | 1.0 Request and Finalize Safety Data | 20d | 2024-01-09 | 2024-02-06 | 4 | 77d | 5d |
| 4 | 1.1.2 | 2.0 Request Project Number, PIN, and Task Profile Numbers | 5d | 2024-01-02 | 2024-01-08 |  | 67d | 0d |
| 5 | 1.1.3 | 3.0 Coordinate with Long Range Planning | 5d | 2024-01-09 | 2024-01-16 | 4 | 102d | 20d |
| 6 | 1.1.4 | 4.0 Request and Finalize Traffic Data | 25d | 2024-01-09 | 2024-02-13 | 4 | 72d | 0d |
| 7 | 1.1.5 | 5.0 Request Preliminary Survey Data | 5d | 2024-01-09 | 2024-01-16 | 4 | 67d | 0d |
| 8 | 1.1.6 | 6.0 Initiate Division Reviews | 5d | 2024-02-14 | 2024-02-21 | 3, 5, 6, 7 | 82d | 0d |
| 9 | 1.2 | **0SD2 Develop Conceptual Layout and Complete Site Visit** | 60d | 2024-02-14 | 2024-05-09 |  | 72d |  |
| 10 | 1.2.1 | 1.0 Conduct Intersection and Interchange Evaluation (IIE) (and traffic analysis) | 25d | 2024-02-14 | 2024-03-20 | 6, 3 | 461d |  |
| 11 | 1.2.2 | 2.0 Complete Conceptual Signal Warrants | 15d | 2024-02-14 | 2024-03-06 | 6 | 421d | 0d |
| 12 | 1.2.3 | 3.0 Develop Draft Conceptual Layouts/Crash Figures for Site Visit | 15d | 2024-02-22 | 2024-03-13 | 3, 6, 7, 52 | 67d | 0d |
| 13 | 1.2.4 | 4.0 Compile Initial Divisional Reviews for Site Visit | 10d | 2024-03-28 | 2024-04-11 | 42, 55, 34, 38, 64, 65, 47 | 67d | 0d |
| 14 | 1.2.5 | 5.0 Prepare Site Visit Packet and Lead Site Visit | 5d | 2024-04-12 | 2024-04-18 | 13, 12 | 67d | 0d |
| 15 | 1.2.6 | 6.0 Initiate IAR Concept Coordination with FHWA | 40d | 2024-03-14 | 2024-05-09 | 6, 12 | 426d |  |
| 16 | 1.3 | **0SD3 Develop Draft Concept Report** | 20d | 2024-04-19 | 2024-05-16 |  | 391d |  |
| 17 | 1.3.1 | 1.0 Develop, Compile, and Distribute the Draft Concept Report | 20d | 2024-04-19 | 2024-05-16 | 12, 3, 6, 14 | 391d | 0d |
| 18 | 1.3.2 | 2.0 Develop Environmental Technical Study Area (ETSA) | 10d | 2024-04-19 | 2024-05-02 | 12, 3, 6, 14 | 411d | 20d |
| 19 | 1.4 | **0SD4 Finalize Concept Report** | 125d? | 2024-01-02 | 2024-07-01 |  | 391d |  |
| 20 | 1.4.1 | 1.0 Prepare Initial Risk Assessment | 5d | 2024-04-12 | 2024-04-18 | 13 | 441d |  |
| 21 | 1.4.2 | 2.0 Finalize Conceptual Layouts | 10d | 2024-05-17 | 2024-05-31 | 12, 65, 64, 59, 45, 61, 17 | 391d | 0d |
| 22 | 1.4.3 | 3.0 Finalize Environmental Technical Study Area (ETSA) | 5d | 2024-06-03 | 2024-06-07 | 18, 17, 21 | 391d | 0d |
| 23 | 1.4.4 | 4.0 Address Comments and Finalize the Concept Report | 10d | 2024-06-10 | 2024-06-24 | 21, 69, 70, 22 | 391d | 0d |
| 24 | 1.4.5 | 5.0 Request for Concept Report Signature(s) and Distribution | 5d | 2024-06-25 | 2024-07-01 | 23 | 391d | 0d |
| 25 | 1.4.6 | 6.0 Develop RSA No Plans Document | 1d? | 2024-01-02 | 2024-01-02 |  | 515d |  |

Notes:
- 4: If using the schedule that includes Stage 0, set your schedule off of this activity.
- 10: And complete needed traffic analysis (25 days total for both items)
- 20: Best practice to have this around the time of the site reviews or could be done during the site review
- 25: If needed, tie up accordingly

| ID | WBS | Task | Duration | Start | Finish | Predecessors | Total slack | Free slack |
| --- | --- | --- | --- | --- | --- | --- | --- | --- |
| 26 | 1.5 | **0SD5 Develop State Industrial Access (SIA) Packet** | 20d? | 2024-01-02 | 2024-01-30 |  | 496d |  |
| 27 | 1.5.1 | 1.0 Receive Draft Application or Initial Request | 1d? | 2024-01-02 | 2024-01-02 |  | 515d |  |
| 28 | 1.5.2 | 2.0 Lead Site Visit | 1d? | 2024-01-02 | 2024-01-02 |  | 515d |  |
| 29 | 1.5.3 | 3.0 Develop Conceptual Layout, Cost Estimate, and Environmental Technical Study Area (ETSA) | 10d | 2024-01-02 | 2024-01-16 |  | 506d |  |
| 30 | 1.5.4 | 4.0 Conduct Benefit-Cost Analysis | 20d | 2024-01-02 | 2024-01-30 |  | 496d |  |
| 31 | 1.5.5 | 5.0 Develop Letter(s) of Approval | 5d | 2024-01-02 | 2024-01-08 |  | 511d |  |
| 32 | 1.5.6 | 6.0 Finalize the SIA Packet | 1d? | 2024-01-02 | 2024-01-02 |  | 515d |  |
| 33 | 1.6 | **0EN1 Conduct Environmental Desktop Review** | 70d | 2024-02-22 | 2024-05-31 |  | 82d |  |
| 34 | 1.6.1 | 1.0 Identify Known Environmental Resource Information | 10d | 2024-02-22 | 2024-03-06 | 8 | 82d | 15d |
| 35 | 1.6.2 | 2.0 Attend Site Visit | 1d | 2024-04-12 | 2024-04-12 | 13 | 445d |  |
| 36 | 1.6.3 | 3.0 Review the Concept Report | 10d | 2024-05-17 | 2024-05-31 | 17 | 411d |  |
| 37 | 1.7 | **0GT1 Conduct Preliminary Geotechnical Assessment** | 70d | 2024-02-22 | 2024-05-31 |  | 82d |  |
| 38 | 1.7.1 | 1.0 Complete Geotechnical Division Review | 10d | 2024-02-22 | 2024-03-06 | 8 | 82d | 15d |
| 39 | 1.7.2 | 2.0 Attend Site Visit | 1d | 2024-04-19 | 2024-04-19 | 14 | 440d |  |
| 40 | 1.7.3 | 3.0 Review the Concept Report | 10d | 2024-05-17 | 2024-05-31 | 17 | 411d |  |
| 41 | 1.8 | **0MM1 Conduct Multimodal Review** | 55d | 2024-03-14 | 2024-05-31 |  | 67d |  |
| 42 | 1.8.1 | 1.0 Conduct Multimodal Review | 10d | 2024-03-14 | 2024-03-27 | 12 | 67d | 0d |
| 43 | 1.8.2 | 2.0 Attend Site Visit | 1d | 2024-04-19 | 2024-04-19 | 14 | 67d | 0d |
| 44 | 1.8.3 | 3.0 Review the Concept Report | 10d | 2024-05-17 | 2024-05-31 | 17 | 411d |  |
| 45 | 1.8.4 | 4.0 Develop Multimodal Considerations & Recommendations | 15d | 2024-04-22 | 2024-05-10 | 42, 43 | 67d | 0d |
| 46 | 1.9 | **0RD1 Provide Roadway Desktop Review** | 70d | 2024-02-22 | 2024-05-31 |  | 82d |  |
| 47 | 1.9.1 | 1.0 Complete Roadway Division Review | 10d | 2024-02-22 | 2024-03-06 | 8 | 82d | 15d |
| 48 | 1.9.2 | 2.0 Attend Site Visit | 1d | 2024-04-19 | 2024-04-19 | 14 | 440d |  |
| 49 | 1.9.3 | 3.0 Review the Concept Report | 10d | 2024-05-17 | 2024-05-31 | 17 | 411d |  |

Notes:
- 26: If applicable for SIA projects; tie up accordingly

| ID | WBS | Task | Type | Duration | Start | Finish | Predecessors | Total slack | Free slack | Constraint |
| --- | --- | --- | --- | --- | --- | --- | --- | --- | --- | --- |
| 50 | 1.10 | **0SY1 Provide Preliminary Survey Data** |  | 30d | 2024-01-17 | 2024-02-28 |  | 67d |  |  |
| 51 | 1.10.1 | 1.0 Set Control Ground Survey |  | 5d | 2024-01-17 | 2024-01-23 | 7 | 67d | 0d |  |
| 52 | 1.10.2 | 2.0 Provide Preliminary Survey Data |  | 20d | 2024-01-24 | 2024-02-21 | 51 | 67d | 0d |  |
| 53 | 1.10.3 | 3.0 Determine Time to Complete the Aerial Survey |  | 5d | 2024-02-22 | 2024-02-28 | 52 | 476d |  |  |
| 54 | 1.11 | **0TO1 Conduct Initial Traffic Ops/TSMO Review** |  | 75d | 2024-02-14 | 2024-05-31 |  | 87d |  |  |
| 55 | 1.11.1 | 1.0 TSMO Alignment & Operations Review |  | 10d | 2024-02-14 | 2024-02-28 | 4, 6 | 87d | 20d |  |
| 56 | 1.11.2 | 2.0 Attend Site Visit |  | 1d | 2024-04-19 | 2024-04-19 | 14 | 440d |  |  |
| 57 | 1.11.3 | 3.0 Review the Concept Report |  | 10d | 2024-05-17 | 2024-05-31 | 17 | 411d |  |  |
| 58 | 1.12 | **0TO2 Develop TSMO Scope Items** |  | 45d | 2024-03-07 | 2024-05-09 |  | 421d |  |  |
| 59 | 1.12.1 | 1.0 Analyze Signal Warrants |  | 20d | 2024-03-07 | 2024-04-04 | 11, 6 | 421d | 20d |  |
| 60 | 1.12.2 | 2.0 Analyze Lighting Warrants |  | 5d | 2024-03-07 | 2024-03-13 | 11 | 461d | 35d |  |
| 61 | 1.12.3 | 3.0 Prepare TSMO & ITS Scope and Budget |  | 10d | 2024-04-19 | 2024-05-02 | 12, 14 | 401d | 0d |  |
| 62 | 1.12.4 | 4.0 Complete SSEA Form or SEA Report |  | 5d | 2024-05-03 | 2024-05-09 | 59, 60, 61 | 426d |  |  |
| 63 | 1.13 | **0ST1 Develop Structures Recommendations** |  | 70d | 2024-02-22 | 2024-05-31 |  | 82d |  |  |
| 64 | 1.13.1 | 1.0 Recommend Structure Type for the Concept Report |  | 10d | 2024-02-22 | 2024-03-06 | 8 | 82d | 15d |  |
| 65 | 1.13.2 | 2.0 Provide Hydraulic Recommendations for the Concept Report |  | 10d | 2024-02-22 | 2024-03-06 | 8 | 82d | 15d |  |
| 66 | 1.13.3 | 3.0 Attend Site Visit |  | 1d | 2024-04-19 | 2024-04-19 | 14 | 440d |  |  |
| 67 | 1.13.4 | 4.0 Review the Concept Report |  | 10d | 2024-05-17 | 2024-05-31 | 17 | 411d |  |  |
| 68 | 1.14 | **0UT1 Complete Utility Preliminary Estimates** |  | 10d | 2024-05-17 | 2024-05-31 |  | 396d |  |  |
| 69 | 1.14.1 | 1.0 Prepare Preliminary Utility Estimate |  | 10d | 2024-05-17 | 2024-05-31 | 12, 17 | 396d | 5d |  |
| 70 | 1.14.2 | 2.0 Prepare Preliminary Railroad Cost Estimate |  | 10d | 2024-05-17 | 2024-05-31 | 12, 17 | 396d | 5d |  |
| 71 | 1.14.3 | 3.0 Review the Concept Report |  | 1d | 2024-05-17 | 2024-05-17 | 17 | 420d |  |  |
| 72 | 2 | Stage 0 Complete | milestone | 0d | 2024-07-01 | 2024-07-01 | 24 | 391d |  |  |
| 73 | 3 | **STAGE 1- CONTEXT/SCOPING** |  | 275d? | 2024-01-02 | 2025-02-07 |  | 0d |  |  |
| 74 | 3.1 | **1PM1 Set Up Project** |  | 31d | 2024-01-02 | 2024-02-14 |  | 0d |  |  |
| 75 | 3.1.1 | 1.0 Confirm Project Assignment |  | 1d | 2024-01-02 | 2024-01-02 |  | 0d |  | must start on 2024-01-02 |
| 76 | 3.1.2 | 2.0 Request Shared Project Folder |  | 10d | 2024-01-03 | 2024-01-17 | 75 | 495d |  |  |
| 77 | 3.1.3 | 3.0 Prepare Draft Project Scope |  | 20d | 2024-01-03 | 2024-01-31 | 75 | 475d | 0d |  |
| 78 | 3.1.4 | 4.0 Prepare Preliminary Schedule |  | 20d | 2024-01-03 | 2024-01-31 | 75 | 470d | 0d |  |

Notes:
- 52: If needed

| ID | WBS | Task | Duration | Start | Finish | Predecessors | Total slack | Free slack |
| --- | --- | --- | --- | --- | --- | --- | --- | --- |
| 79 | 3.1.5 | **5.0 Validate Preliminary Budget** | 20d | 2024-01-03 | 2024-01-31 | 75 | 475d |  |
| 80 | 3.1.5.1 | - Validate Preliminary Budget | 20d | 2024-01-03 | 2024-01-31 | 75 | 475d | 0d |
| 81 | 3.1.5.2 | - Confirm/Coordinate Approval of Project in the STIP/TIP | 10d | 2024-01-03 | 2024-01-17 | 75 | 495d |  |
| 82 | 3.1.6 | 6.0 Prepare Draft Quality Management Plan | 10d | 2024-01-03 | 2024-01-17 | 75 | 495d |  |
| 83 | 3.1.7 | 7.0 Prepare Draft Risk Management Plan | 20d | 2024-01-03 | 2024-01-31 | 75 | 485d |  |
| 84 | 3.1.8 | 8.0 Prepare Draft Project Communication Plan | 5d | 2024-01-03 | 2024-01-09 | 75 | 500d |  |
| 85 | 3.1.9 | 9.0 Prepare Draft Project Commitment Document (PCD) | 10d | 2024-02-01 | 2024-02-14 | 77, 78, 80 | 475d |  |
| 86 | 3.1.10 | 10.0 Request and Obtain Authorization of Funds (PE-N and Incidentals) | 5d | 2024-01-03 | 2024-01-09 | 75 | 500d |  |
| 87 | 3.2 | **1PM2 Build Project Team** | 36d | 2024-01-03 | 2024-02-23 |  | 0d |  |
| 88 | 3.2.1 | 1.0 Identify Project Team Resources | 10d | 2024-01-03 | 2024-01-17 | 75 | 6d | 0d |
| 89 | 3.2.2 | 2.0 Build Project Team | 20d | 2024-01-18 | 2024-02-14 | 88 | 6d | 0d |
| 90 | 3.2.3 | 3.0 Determine Type of Consultant(s) and Contract(s) Required | 6d | 2024-01-03 | 2024-01-10 | 75 | 0d |  |
| 91 | 3.2.4 | 4.0 Obtain Consultant(s) | 30d | 2024-01-11 | 2024-02-23 | 90 | 0d |  |
| 92 | 3.3 | **1PM3 Hold Kickoff Meeting** | 7d | 2024-02-15 | 2024-02-26 |  | 6d |  |
| 93 | 3.3.1 | 1.0 Set Up Meeting and Develop Agenda | 5d | 2024-02-15 | 2024-02-22 | 89 | 480d |  |
| 94 | 3.3.2 | 2.0 Hold Meeting and Document/Distribute Minutes | 1d | 2024-02-26 | 2024-02-26 | 89, 91 | 0d |  |
| 95 | 3.3.3 | 3.0 Verify the ETSA | 1d | 2024-02-26 | 2024-02-26 | 89, 91 | 1d | 0d |
| 96 | 3.4 | **1PM4 Conduct Initial Risk Workshop** | 244d | 2024-02-15 | 2025-02-07 |  | 241d |  |
| 97 | 3.4.1 | 1.0 Set Up Meeting and Develop Agenda | 1d | 2024-02-15 | 2024-02-15 | 89 | 484d |  |
| 98 | 3.4.2 | 2.0 Hold Meeting and Document/Distribute Minutes | 1d | 2024-02-26 | 2024-02-26 | 89, 91 | 478d |  |
| 99 | 3.4.3 | **3.0 Update and Monitor Risk Register** | 177d | 2024-05-22 | 2025-02-07 |  | 241d |  |
| 100 | 3.4.3.1 | - Risk Update #1 | 1d | 2024-05-22 | 2024-05-22 | 141FS+5d | 417d |  |
| 101 | 3.4.3.2 | - Risk Update #2 | 1d | 2024-09-25 | 2024-09-25 | 271FS+5d | 331d |  |
| 102 | 3.4.3.3 | - Risk Update #3 | 1d | 2025-02-07 | 2025-02-07 | 325FS+5d | 241d |  |

Notes:
- 86: To include PE-N and ROW/Utility Incidentals, if not already authorized
- 95: As needed and could be done at the kickoff meeting
- 97: Could be held with the kickoff meeting (logic assumes that right now; adjust as needed).
- 98: Could be held with the kickoff meeting (logic assumes that right now; adjust as needed).

| ID | WBS | Task | Duration | Start | Finish | Predecessors | Total slack | Free slack |
| --- | --- | --- | --- | --- | --- | --- | --- | --- |
| 103 | 3.5 | **1SY1 Conduct Design-Level Survey** | 68d? | 2024-01-02 | 2024-04-09 |  | 83d |  |
| 104 | 3.5.1 | 1.0 Prepare the Ground Control for Aerial Survey | 10d | 2024-01-02 | 2024-01-16 |  | 481d | 0d |
| 105 | 3.5.2 | 2.0 Complete the Aerial Survey | 25d | 2024-01-17 | 2024-02-21 | 104 | 481d |  |
| 106 | 3.5.3 | 3.0 Set Control Ground Survey | 5d | 2024-01-03 | 2024-01-09 | 75 | 82d | 0d |
| 107 | 3.5.4 | 4.0 Conduct Survey Public Involvement and Ground Survey | 1d? | 2024-01-10 | 2024-01-10 | 106 | 82d | 31d |
| 108 | 3.5.5 | 5.0 Incorporate SUE Request into Survey | 10d | 2024-03-26 | 2024-04-09 | 112SS-20d, 115SS+20d | 448d |  |
| 109 | 3.6 | **1RD1 Initiate Roadway Design** | 45d? | 2024-02-27 | 2024-04-30 |  | 1d |  |
| 110 | 3.6.1 | 1.0 Establish Project-Specific Design Criteria | 10d | 2024-02-27 | 2024-03-11 | 94, 107FS-20d | 31d | 30d |
| 111 | 3.6.2 | 2.0 Determine Work Zone Significance | 10d | 2024-02-27 | 2024-03-11 | 94, 107FS-20d | 31d | 30d |
| 112 | 3.6.3 | 3.0 Develop Line, Grade, and Cross Sections (Line and Grade Package) | 1d? | 2024-04-23 | 2024-04-23 | 94, 107FS-20d, 123FF+20d | 1d | 0d |
| 113 | 3.6.4 | 4.0 Compile the Line and Grade Package for Field Review | 5d | 2024-04-24 | 2024-04-30 | 112, 110, 111 | 1d | 0d |
| 114 | 3.7 | **1UT1 Begin Third-Party (Utilities & Railroad) Coordination** | 51d | 2024-02-27 | 2024-05-08 |  | 0d |  |
| 115 | 3.7.1 | 1.0 Make Initial Utility Contact | 50d | 2024-02-27 | 2024-05-07 | 94 | 0d |  |
| 116 | 3.7.2 | 2.0 Conduct Utility Coordination Kickoff Meeting | 1d | 2024-05-08 | 2024-05-08 | 115 | 0d |  |
| 117 | 3.7.3 | 3.0 Initiate Railroad Coordination | 50d | 2024-02-27 | 2024-05-07 | 94 | 428d |  |
| 118 | 3.8 | **1EN1 Complete Environmental Resource Identification** | 50d | 2024-02-27 | 2024-05-07 |  | 1d |  |
| 119 | 3.8.1 | 1.0 Identify Historic Property Boundary(ies) and Initiate Agency Coordination | 50d | 2024-02-27 | 2024-05-07 | 94, 95 | 312d | 0d |
| 120 | 3.8.2 | 2.0 Identify Boundary(ies) for Potentially Eligible Archaeology Sites and Initiate Agency Coordination | 50d | 2024-02-27 | 2024-05-07 | 94, 95 | 193d | 0d |
| 121 | 3.8.3 | 3.0 Conduct Native American Coordination to Identify Consulting Parties | 50d | 2024-02-27 | 2024-05-07 | 94, 95 | 428d |  |
| 122 | 3.8.4 | **4.0 Identify Ecology Site Boundaries** | 50d | 2024-02-27 | 2024-05-07 |  | 1d | 0d |
| 123 | 3.8.4.1 | - Develop and send shapefiles of features to design | 20d | 2024-02-27 | 2024-03-25 | 94, 95 | 1d | 0d |
| 124 | 3.8.4.2 | - Complete an Environmental Boundaries Report (EBR) | 50d | 2024-02-27 | 2024-05-07 | 94, 95 | 1d |  |
| 125 | 3.8.5 | 5.0 Establish Air Quality Designation | 50d | 2024-02-27 | 2024-05-07 | 94, 95 | 312d | 0d |
| 126 | 3.8.6 | 6.0 Identify Potential Noise Receptor Locations | 50d | 2024-02-27 | 2024-05-07 | 94, 95 | 193d | 0d |
| 127 | 3.8.7 | 7.0 Identify Potential Hazardous Materials Sites | 50d | 2024-02-27 | 2024-05-07 | 94, 95 | 312d | 0d |
| 128 | 3.8.8 | 8.0 Identify Section 4(f) and Section 6(f) Resources | 50d | 2024-02-27 | 2024-05-07 | 94, 95 | 428d |  |

Notes:
- 104: Tie up to when it is best done seasonally
- 107: To included picking up utilities, property information, and potentially staked ecology features (OHWM, steams, ephemerals, wetlands) amongst other standard survey items.
- 108: Potential early task
- 110: Could start right after the kickoff meeting or after the kickoff meeting and completion of ground survey
- 112: Duration depends on size of the project/complexity of design, and can be run parallel with survey, but team will likely need at least a month to tie in survey.
- 122: Recommend the data collection/field survey work for ecology be done ASAP in Stage 1 (while survey is modelized in 1SY1), so that the shapefiles can be incorporated into the Line and Grade Package before finalizing. If the shapefiles are available prior to the EBR, tie all associated schedule logic to the subtask, "Develop and send shapefiles of features to design."

| ID | WBS | Task | Type | Duration | Start | Finish | Predecessors | Baseline start | Baseline finish | Baseline duration | Total slack | Free slack | Text1 |
| --- | --- | --- | --- | --- | --- | --- | --- | --- | --- | --- | --- | --- | --- |
| 129 | 3.9 | **1GT1 Develop Geotechnical Work Plan** |  | 50d | 2024-02-27 | 2024-05-07 |  |  |  |  | 45d |  |  |
| 130 | 3.9.1 | 1.0 Gather Relevant Geotechnical Information |  | 5d | 2024-02-27 | 2024-03-04 | 94 |  |  |  | 50d | 0d |  |
| 131 | 3.9.2 | 2.0 Complete Project-Specific Geotechnical Investigation |  | 10d | 2024-03-05 | 2024-03-18 | 107, 130 |  |  |  | 50d | 5d |  |
| 132 | 3.9.3 | 3.0 Identify Project Type and Potential Mitigation Strategies |  | 20d | 2024-03-26 | 2024-04-23 | 131, 112FS-20d |  |  |  | 45d | 0d |  |
| 133 | 3.9.4 | 4.0 Develop Geotechnical Work Plan |  | 10d | 2024-04-24 | 2024-05-07 | 130, 113FS-20d, 132, 185, 234 |  |  |  | 45d | 0d |  |
| 134 | 3.10 | **1ST1 Complete Existing and No Structure Modeling** |  | 20d | 2024-02-27 | 2024-03-25 |  |  |  |  | 458d |  |  |
| 135 | 3.10.1 | 1.0 Hydraulically Model Existing and No Structure Conditions |  | 20d | 2024-02-27 | 2024-03-25 | 94, 107 |  |  |  | 458d |  |  |
| 136 | 3.11 | **1TO1 Validate Analysis and Determine Significance** |  | 10d? | 2024-02-27 | 2024-03-11 |  |  |  |  | 468d |  |  |
| 137 | 3.11.1 | 1.0 Validate Traffic Analysis |  | 1d? | 2024-02-27 | 2024-02-27 | 94 |  |  |  | 477d |  |  |
| 138 | 3.11.2 | 2.0 Determine Work Zone Significance |  | 10d | 2024-02-27 | 2024-03-11 | 94, 107FS-20d |  |  |  | 468d |  |  |
| 139 | 3.12 | **1PM5 Hold Scoping Meeting and Site Review** |  | 25d | 2024-04-17 | 2024-05-21 |  |  |  |  | 70d |  |  |
| 140 | 3.12.1 | 1.0 Set Up Meeting and Develop Agenda |  | 1d | 2024-04-17 | 2024-04-17 | 141SS-10d |  |  |  | 442d |  |  |
| 141 | 3.12.2 | 2.0 Review and Complete Comment Form |  | 10d | 2024-05-01 | 2024-05-14 | 113 |  |  |  | 60d | 0d |  |
| 142 | 3.12.3 | 3.0 Compile Comments, Hold Meeting, and Document/Distribute Minutes |  | 5d | 2024-05-15 | 2024-05-21 | 141 | 2022-07-07 | 2022-07-20 | 10.67d | 60d | 0d | Yes |
| 143 | 3.12.4 | 4.0 Estimate the Project Using the Line and Grade Package |  | 10d | 2024-05-01 | 2024-05-14 | 113 |  |  |  | 378d | 0d |  |
| 144 | 3.12.5 | 5.0 Determine Need for Value Engineering |  | 5d | 2024-05-15 | 2024-05-21 | 141, 143 |  |  |  | 378d | 0d |  |
| 145 | 4 | Stage 1 Complete | milestone | 0d | 2024-05-21 | 2024-05-21 | 142 |  |  |  | 418d |  |  |
| 146 | 5 | **STAGE 2- FOOTPRINT ESTABLISHED** |  | 304d? | 2024-01-02 | 2025-03-21 |  |  |  |  | 84d |  |  |
| 147 | 5.1 | **2PM1 Manage Project** |  | 304d? | 2024-01-02 | 2025-03-21 |  |  |  |  | 212d |  |  |
| 148 | 5.1.1 | **1.0 Develop Project Management Plan** |  | 92d | 2024-02-15 | 2024-06-27 |  |  |  |  | 393d |  |  |
| 149 | 5.1.1.1 | - Develop PMP |  | 10d | 2024-02-15 | 2024-02-29 | 74 |  |  |  | 475d |  |  |
| 150 | 5.1.1.2 | - PMP Update 1 |  | 10d | 2024-05-22 | 2024-06-05 | 142 |  |  |  | 408d |  |  |
| 151 | 5.1.1.3 | - PMP Update 2 |  | 5d | 2024-06-21 | 2024-06-27 | 167 |  |  |  | 393d |  |  |
| 152 | 5.1.2 | **2.0 Report Project Status** |  | 5d | 2024-01-02 | 2024-01-08 |  |  |  |  | 511d |  |  |
| 153 | 5.1.2.1 | - Status Update 1 |  | 5d | 2024-01-02 | 2024-01-08 |  |  |  |  | 511d |  |  |
| 154 | 5.1.2.2 | - Status Update 2 |  | 5d | 2024-01-02 | 2024-01-08 |  |  |  |  | 511d |  |  |

Notes:
- 133: Logic may be able to be simplified
- 138: May delete, but coordinate with similar 1RD1 task
- 139: This could serve as the Line and Grade review, if a more formal meeting is not added into the schedule.
- 142: Confirm scope, schedule, budget
- 148: This activity also covers 3PM1 and 4PM1
- 153: Tie up based on occurrence/need
- 154: Tie up based on occurrence/need

| ID | WBS | Task | Duration | Start | Finish | Predecessors | Total slack | Free slack |
| --- | --- | --- | --- | --- | --- | --- | --- | --- |
| 155 | 5.1.3 | **3.0 Finalize Local Government Agreements** | 163d | 2024-01-02 | 2024-08-23 |  | 308d |  |
| 156 | 5.1.3.1 | - Enter Agreement 1 Name | 80d | 2024-05-01 | 2024-08-23 | 113 | 308d |  |
| 157 | 5.1.3.2 | - Enter Agreement 2 Name | 20d | 2024-01-02 | 2024-01-30 |  | 451d |  |
| 158 | 5.1.4 | **4.0 Perform Letting Readiness Assessment** | 140d | 2024-08-27 | 2025-03-21 |  | 212d |  |
| 159 | 5.1.4.1 | - Functional Design Plans | 5d | 2024-08-27 | 2024-09-03 | 186 | 347d |  |
| 160 | 5.1.4.2 | - Plan-in-Hand | 5d | 2025-01-16 | 2025-01-23 | 279 | 252d |  |
| 161 | 5.1.4.3 | - Construction Documents | 5d | 2025-03-17 | 2025-03-21 | 331 | 212d |  |
| 162 | 5.1.5 | 5.0 Support Value Engineering Efforts | 40d | 2024-05-22 | 2024-07-19 | 144, 142 | 378d |  |
| 163 | 5.1.6 | 6.0 Manage Consultant Contracts and Modifications | 1d? | 2024-02-26 | 2024-02-26 | 75, 91 | 478d |  |
| 164 | 5.2 | **2PM2 Complete Project Commitment Document (PCD)** | 20d | 2024-05-22 | 2024-06-20 |  | 393d |  |
| 165 | 5.2.1 | 1.0 Verify Schedule | 10d | 2024-05-22 | 2024-06-05 | 78, 142 | 393d | 0d |
| 166 | 5.2.2 | 2.0 Verify Estimates | 10d | 2024-05-22 | 2024-06-05 | 142, 210, 209, 196, 143 | 393d | 0d |
| 167 | 5.2.3 | 3.0 Finalize Project Commitment Document (PCD) | 10d | 2024-06-06 | 2024-06-20 | 166, 165 | 393d | 0d |
| 168 | 5.3 | **2SY1 Complete SUE and Requested Staking** | 61d | 2024-05-08 | 2024-08-05 |  | 21d |  |
| 169 | 5.3.1 | 1.0 Incorporate SUE Level A and B Request into Survey | 40d | 2024-06-07 | 2024-08-05 | 208, 173 | 0d |  |
| 170 | 5.3.2 | 2.0 Stake Sounding Holes | 10d | 2024-05-08 | 2024-05-21 | 133 | 257d | 0d |
| 171 | 5.4 | **2RD1 Develop Functional Design Plans** | 136d? | 2024-04-03 | 2024-10-15 |  | 21d |  |
| 172 | 5.4.1 | 1.0 Develop a Utility Impact/Conflict Matrix | 10d | 2024-05-09 | 2024-05-22 | 116, 113 | 0d |  |
| 173 | 5.4.2 | 2.0 Identify Initial Subsurface Utility Engineering (SUE) Needs | 15d | 2024-05-01 | 2024-05-21 | 113 | 1d |  |
| 174 | 5.4.3 | **3.0 Request Pavement Design** | 47d | 2024-05-01 | 2024-07-09 |  | 55d |  |
| 175 | 5.4.3.1 | - Request initial pavement design | 1d | 2024-05-01 | 2024-05-01 | 113 | 55d | 0d |
| 176 | 5.4.3.2 | - Receive and incorporate draft pavement design | 10d | 2024-05-16 | 2024-05-30 | 193 | 55d |  |
| 177 | 5.4.3.3 | - Request final pavement design | 1d | 2024-05-23 | 2024-05-23 | 216 | 386d | 0d |
| 178 | 5.4.3.4 | - Receive and incorporate final pavement design | 20d | 2024-06-10 | 2024-07-09 | 194 | 386d |  |
| 179 | 5.4.4 | 4.0 Document Design Exceptions and Waivers | 20d | 2024-05-01 | 2024-05-29 | 113 | 56d |  |
| 180 | 5.4.5 | 5.0 Incorporate SUE Data and Lead Internal Design Deconfliction Meeting | 10d | 2024-08-06 | 2024-08-19 | 169 | 0d |  |
| 181 | 5.4.6 | 6.0 Develop Utility Coordination Plans | 30d | 2024-05-01 | 2024-06-12 | 113 | 137d | 0d |
| 182 | 5.4.7 | 7.0 Develop Design and Sketches for Permit Applications | 30d | 2024-05-22 | 2024-07-05 | 113, 251 | 286d | 0d |
| 183 | 5.4.8 | 8.0 Develop Conceptual Traffic Control Strategies | 20d | 2024-05-01 | 2024-05-29 | 113 | 56d | 0d |
| 184 | 5.4.9 | 9.0 Develop the Functional Design Plans | 1d? | 2024-05-22 | 2024-05-22 | 142 | 60d |  |
| 185 | 5.4.10 | 10.0 Coordinate Geotechnical Analysis for Noise and Retaining Walls | 10d | 2024-04-03 | 2024-04-16 | 113FS-20d | 50d | 5d |
| 186 | 5.4.11 | 11.0 Compile the Functional Design Plans and Participate in the Field Review | 5d | 2024-08-20 | 2024-08-26 | 267, 217, 243, 263, 265, 266, 183, 184, 191, 230, 229, 233, 176, 179, 180 | 0d |  |
| 187 | 5.4.12 | 12.0 Revise and Submit Updated Functional Design Plans | 15d | 2024-09-25 | 2024-10-15 | 272 | 0d |  |

Notes:
- 156: Check duration and logic for each project
- 157: Need to tie up if additional agreements are needed
- 163: Runs the length of the project; could be inactivated for each project
- 172: Or use related line under 2UT1
- 177: Tie up based on plan set refinement either prior to Functional Design Plans or in Stage 3 for the Plan-in-Hand Plans
- 181: This could begin in Stage 2 or early Stage 3. Consider advancing at risk if the project is under an accelerated schedule.
- 184: Duration depends on size of the project/complexity of design.

| ID | WBS | Task | Duration | Start | Finish | Predecessors | Total slack | Free slack |
| --- | --- | --- | --- | --- | --- | --- | --- | --- |
| 188 | 5.5 | **2RD2 Conduct Design Public Meeting** | 66d | 2024-05-01 | 2024-08-05 |  | 10d |  |
| 189 | 5.5.1 | 1.0 Prepare for the Design Public Meeting | 55d | 2024-05-01 | 2024-07-19 | 113 | 10d | 0d |
| 190 | 5.5.2 | 2.0 Hold Design Public Meeting | 1d | 2024-07-22 | 2024-07-22 | 189 | 10d | 0d |
| 191 | 5.5.3 | 3.0 Process Design Public Meeting Transcript | 10d | 2024-07-23 | 2024-08-05 | 190 | 10d |  |
| 192 | 5.6 | **2PV1 Provide Pavement Design** | 26d | 2024-05-02 | 2024-06-07 |  | 55d |  |
| 193 | 5.6.1 | 1.0 Provide Draft Pavement Design | 10d | 2024-05-02 | 2024-05-15 | 175 | 55d | 0d |
| 194 | 5.6.2 | 2.0 Provide Final Pavement Design | 10d | 2024-05-24 | 2024-06-07 | 177 | 386d | 0d |
| 195 | 5.7 | **2RW1 Initiate Pre-Acquisition Activities** | 40d | 2024-05-01 | 2024-06-27 |  | 247d |  |
| 196 | 5.7.1 | 1.0 Prepare Right-of-Way Estimate | 10d | 2024-05-01 | 2024-05-14 | 113 | 398d | 5d |
| 197 | 5.7.2 | 2.0 Perform Title Searches | 20d | 2024-05-01 | 2024-05-29 | 113 | 247d | 0d |
| 198 | 5.7.3 | 3.0 Initiate Private Property Owner Utility Adjustment | 20d | 2024-05-30 | 2024-06-27 | 113, 197 | 247d | 41d |
| 199 | 5.7.4 | 4.0 Initiate PGI Field Work | 20d | 2024-05-30 | 2024-06-27 | 197, 113 | 247d | 41d |
| 200 | 5.8 | **2PM3 Conduct ROW Strategy Meeting(s)** | 124d | 2024-01-02 | 2024-06-28 |  | 392d |  |
| 201 | 5.8.1 | 1.0 Set Up Meeting and Develop Agenda | 1d | 2024-05-01 | 2024-05-01 | 113 | 392d | 0d |
| 202 | 5.8.2 | 2.0 Hold Meeting and Document/Distribute Minutes | 40d | 2024-05-02 | 2024-06-28 | 201, 113 | 392d |  |
| 203 | 5.8.3 | 3.0 Attend ROW Site Visit and Collect Feedback | 1d | 2024-01-02 | 2024-01-02 |  | 515d |  |
| 204 | 5.9 | **2RW2 Execute ROW Proposal** | 2d? | 2024-05-01 | 2024-05-02 |  | 386d |  |
| 205 | 5.9.1 | 1.0 Prepare/Submit ROW Proposal | 1d? | 2024-05-01 | 2024-05-01 | 113 | 386d | 0d |
| 206 | 5.9.2 | 2.0 Receive ROW Proposal and Distribute for Execution | 1d? | 2024-05-02 | 2024-05-02 | 205 | 386d |  |
| 207 | 5.10 | **2UT1 Utility/Railroad Pre-Acquisition Activities** | 86d | 2024-05-01 | 2024-09-03 |  | 16d |  |
| 208 | 5.10.1 | 1.0 Coordinate/Request Needed SUE | 10d | 2024-05-23 | 2024-06-06 | 172, 173 | 0d |  |
| 209 | 5.10.2 | 2.0 Prepare Utility Estimate | 10d | 2024-05-01 | 2024-05-14 | 113 | 398d | 5d |
| 210 | 5.10.3 | 3.0 Prepare Railroad Estimates | 10d | 2024-05-01 | 2024-05-14 | 113 | 398d | 5d |
| 211 | 5.10.4 | 4.0 Develop a Utility Impact/Conflict Matrix | 10d | 2024-05-09 | 2024-05-22 | 116, 113 | 417d |  |
| 212 | 5.10.5 | 5.0 Review SUE Data and Attend Internal Design Deconfliction Meeting | 20d | 2024-08-06 | 2024-09-03 | 169 | 347d |  |

Notes:
- 189: Public meeting requests need to be submitted 8 weeks before the public meeting to CRD. Public Hearing requests must be submitted to CRD with this checklist ten (10) weeks in advance of hearing date.
- 197: Duration will depend on number of acquisitions/relocations
- 199: Duration will depend on number of acquisitions/relocations
- 202: Meant to either manage meeting-by-meeting or over the course of the meetings
- 203: Various (as many as needed)
- 205: Another name for 2PM1's Local Agency agreements
- 206: Another name for 2PM1's Local Agency agreements
- 208: Coordinate with 2RD1 Task 2.0
- 211: Or use related line under 2RD1

| ID | WBS | Task | Duration | Start | Finish | Predecessors | Total slack | Free slack |
| --- | --- | --- | --- | --- | --- | --- | --- | --- |
| 213 | 5.11 | **2GT1 Complete the Soils and Geology Report** | 114d? | 2024-01-02 | 2024-06-13 |  | 133d |  |
| 214 | 5.11.1 | 1.0 Conduct Site Exploration for Soils and Geology Report | 1d? | 2024-05-08 | 2024-05-08 | 113, 133 | 54d | 9d |
| 215 | 5.11.2 | 2.0 Select the Appropriate Laboratory Testing Program | 10d | 2024-05-08 | 2024-05-21 | 113, 133 | 45d | 0d |
| 216 | 5.11.3 | 3.0 Develop the Soils and Geology Report | 1d? | 2024-05-22 | 2024-05-22 | 214, 215 | 45d | 0d |
| 217 | 5.11.4 | 4.0 Develop Associated Geotechnical Sheet (G-Sheets) | 15d | 2024-05-23 | 2024-06-13 | 216 | 45d |  |
| 218 | 5.11.5 | 5.0 Develop Supporting Project Addenda | 1d? | 2024-01-02 | 2024-01-02 |  | 515d |  |
| 219 | 5.12 | **2GT2 Complete Foundation Reports** | 21d? | 2024-05-22 | 2024-06-21 |  | 257d |  |
| 220 | 5.12.1 | 1.0 Conduct Site Exploration for Structures | 1d? | 2024-05-22 | 2024-05-22 | 113, 133, 170 | 257d | 0d |
| 221 | 5.12.2 | 2.0 Complete and Submit Foundation Report for Retaining Wall(s) | 1d? | 2024-05-23 | 2024-05-23 | 220 | 305d | 108d |
| 222 | 5.12.3 | 3.0 Complete and Submit Foundation Report for Noise Wall(s) | 1d? | 2024-05-23 | 2024-05-23 | 220 | 305d | 108d |
| 223 | 5.12.4 | 4.0 Complete and Submit Standard Report for Signs, Lighting, Signals, ITS, and High-Mast Lighting | 20d | 2024-05-23 | 2024-06-21 | 220 | 257d | 80d |
| 224 | 5.12.5 | 5.0 Complete and Submit Foundation Report for Bridges | 1d? | 2024-05-23 | 2024-05-23 | 220 | 305d | 99d |
| 225 | 5.13 | **2ST1 Complete Hydraulic Design** | 55d | 2024-05-01 | 2024-07-19 |  | 21d |  |
| 226 | 5.13.1 | 1.0 Verify Proposed Grade and Estimate Hydraulic Structure Sizes | 15d | 2024-05-01 | 2024-05-21 | 113 | 21d | 0d |
| 227 | 5.13.2 | 2.0 Develop Draft Hydraulic Layout | 20d | 2024-05-22 | 2024-06-20 | 226 | 21d | 0d |
| 228 | 5.13.3 | 3.0 Hydraulically Model Proposed Conditions, Evaluate Proposals, and Select Appropriate Structure | 20d | 2024-05-22 | 2024-06-20 | 226 | 21d | 0d |
| 229 | 5.13.4 | 4.0 Finalize Hydraulic Layout | 20d | 2024-06-21 | 2024-07-19 | 227, 228 | 21d |  |
| 230 | 5.13.5 | 5.0 Finalize Hydraulic Design Information | 20d | 2024-06-21 | 2024-07-19 | 227, 228 | 21d |  |
| 231 | 5.14 | **2ST2 Develop Preliminary Bridge Plans** | 75d | 2024-04-03 | 2024-07-19 |  | 21d |  |
| 232 | 5.14.1 | 1.0 Review Proposed Grade and Alignment for Non-Hydraulic Crossings | 15d | 2024-05-01 | 2024-05-21 | 113 | 21d | 0d |
| 233 | 5.14.2 | 2.0 Develop Preliminary Bridge Layouts | 40d | 2024-05-22 | 2024-07-19 | 232 | 21d |  |
| 234 | 5.14.3 | 3.0 Coordinate Geotechnical Analysis for Bridges | 5d | 2024-04-03 | 2024-04-09 | 113FS-20d | 55d | 10d |
| 235 | 5.15 | **2EN1 Complete Environmental Resource Effects/Impacts** | 125d? | 2024-05-01 | 2024-10-28 |  | 75d | 0d |
| 236 | 5.15.1 | 1.0 Complete Necessary Resource Effect/Impact Evaluations (all other resources) | 1d? | 2024-05-01 | 2024-05-01 | 113 | 317d |  |
| 237 | 5.15.2 | 2.0 Complete Historic Preservation Effects Study | 1d? | 2024-05-08 | 2024-05-08 | 119, 113 | 312d |  |
| 238 | 5.15.3 | 3.0 Complete Phase Two Archaeological Eligibility Study | 120d | 2024-05-08 | 2024-10-28 | 120, 113 | 193d |  |
| 239 | 5.15.4 | 4.0 Complete Air Quality Impact Study | 1d? | 2024-05-08 | 2024-05-08 | 125, 113 | 312d |  |
| 240 | 5.15.5 | 5.0 Complete Noise Abatement Study | 120d | 2024-05-08 | 2024-10-28 | 126, 113 | 193d | 0d |
| 241 | 5.15.6 | 6.0 Complete Ecology Environmental Boundaries Report | 1d? | 2024-05-08 | 2024-05-08 | 122, 113 | 312d |  |
| 242 | 5.15.7 | 7.0 Complete Hazardous Materials Study | 1d? | 2024-05-08 | 2024-05-08 | 127, 113 | 312d |  |
| 243 | 5.15.8 | 8.0 Confirm Multimodal Compliance Determination | 1d? | 2024-05-13 | 2024-05-13 | 45 | 67d |  |

Notes:
- 218: Tie up as needed
- 223: See PDN; this is likely going to just entail getting the borings and holding them for contractor reference; typically no formal report is needed for signal, signs, and lighting (with the exception of high-mast).
- 235: Depending on the resources in the ETSA, the use or duration for a # of these studies could add considerable schedule time. The studies are required will not be known until the end of Stage 1/start of Stage 2. Adjust durations ASAP.

| ID | WBS | Task | Duration | Start | Finish | Predecessors | Total slack | Free slack | Text1 |
| --- | --- | --- | --- | --- | --- | --- | --- | --- | --- |
| 244 | 5.16 | **2EN2 Complete Environmental Document** | 191d | 2024-05-07 | 2025-02-12 |  | 193d |  |  |
| 245 | 5.16.1 | 1.0 Review/Finalize Purpose and Need Statement | 10d | 2024-05-07 | 2024-05-20 | 112SS+10d | 304d | 111d |  |
| 246 | 5.16.2 | 2.0 Complete Environmental Document | 20d | 2024-10-29 | 2024-11-27 | 235, 245 | 193d | 0d |  |
| 247 | 5.16.3 | 3.0 Receive Approval (as applicable) | 50d | 2024-11-29 | 2025-02-12 | 246 | 193d |  |  |
| 248 | 5.16.4 | 4.0 Functional Design Plans Review (if needed): Complete Environmental Document Re-Evaluation | 15d | 2024-08-27 | 2024-09-17 | 186 | 292d |  | Yes |
| 249 | 5.16.5 | 5.0 Plan-in-Hand Review: Complete Environmental Document Re-Evaluation | 15d | 2025-01-16 | 2025-02-06 | 279 | 197d |  | Yes |
| 250 | 5.17 | **2EN3 Conduct Permit Assessment** | 144d? | 2024-01-02 | 2024-07-29 |  | 369d |  |  |
| 251 | 5.17.1 | 1.0 Complete Permit Assessment | 15d | 2024-05-01 | 2024-05-21 | 113, 123 | 286d | 0d |  |
| 252 | 5.17.2 | 2.0 Finalize Plans and Sketch Review and Prepare Permittable Plans Package | 1d? | 2024-07-08 | 2024-07-08 | 251, 182 | 286d | 0d |  |
| 253 | 5.17.3 | 3.0 Evaluate Permittable Plans Package | 15d | 2024-07-09 | 2024-07-29 | 252 | 286d | 24d |  |
| 254 | 5.17.4 | 4.0 Lead Pre-application meeting with USACE and TDEC | 1d? | 2024-01-02 | 2024-01-02 |  | 515d |  |  |
| 255 | 5.18 | **2PM4 Conduct Permit Strategy Meeting(s)** | 128d? | 2024-01-02 | 2024-07-05 |  | 388d |  |  |
| 256 | 5.18.1 | 1.0 Set Up Meeting and Develop Agenda | 1d? | 2024-05-08 | 2024-05-08 | 122 | 427d |  |  |
| 257 | 5.18.2 | 2.0 Hold Meeting and Document/Distribute Minutes | 40d | 2024-05-08 | 2024-07-05 | 122, 113 | 388d |  |  |
| 258 | 5.18.3 | 3.0 Verify Permit(s) Are Complete and Submitted | 1d? | 2024-01-02 | 2024-01-02 |  | 515d |  |  |
| 259 | 5.19 | **2EN4 Complete Mitigation Assessment and Initiate Mitigation Design** | 70d | 2024-05-08 | 2024-08-16 |  | 1d |  |  |
| 260 | 5.19.1 | **1.0 Complete Mitigation Assessment** | 30d | 2024-05-08 | 2024-06-20 |  | 1d | 0d |  |
| 261 | 5.19.1.1 | - Evaluate mitigation (Bank or In-Lieu fee) availability and permittee responsibilities | 15d | 2024-05-08 | 2024-05-29 | 122, 113 | 1d | 0d |  |
| 262 | 5.19.1.2 | - Identify Need for Concurrent Project | 15d | 2024-05-30 | 2024-06-20 | 261 | 1d |  |  |
| 263 | 5.19.2 | 2.0 Develop Preliminary Mitigation Plan (30% designed) | 40d | 2024-06-21 | 2024-08-16 | 260 | 1d |  |  |
| 264 | 5.20 | **2TO1 Prepare ITS, Signals, and Lighting Sheets** | 40d | 2024-05-01 | 2024-06-27 |  | 36d |  |  |
| 265 | 5.20.1 | 1.0 Prepare TSMO/ITS Device Sheets | 40d | 2024-05-01 | 2024-06-27 | 113 | 36d |  |  |
| 266 | 5.20.2 | 2.0 Prepare Signal Sheets | 40d | 2024-05-01 | 2024-06-27 | 113 | 36d |  |  |
| 267 | 5.20.3 | 3.0 Prepare Lighting Sheets | 40d | 2024-05-01 | 2024-06-27 | 113 | 36d |  |  |
| 268 | 5.20.4 | 4.0 Oversee Development of the Conceptual Traffic Control Strategies | 40d | 2024-05-01 | 2024-06-27 | 183SS | 393d |  |  |

Notes:
- 246: Includes sending FHWA Notice of Intent (if needed)
- 247: Duration assumes FHWA approval of NEPA document; if TEER this can be shorter
- 248: This could be 3 weeks to 6 months depending on impacts/changes in design. This activity is optional depending on if the environmental document is complete at the time the plans are submitted for review.
- 249: This could be 3 weeks to 6 months depending on impacts/changes in design.
- 252: Adjust duration based on complexity of permit impacts.
- 254: Optional task that will help in coordinating with USACE and TDEC on the project details and upcoming permit application and content.
- 257: Meant to either manage meeting-by-meeting or over the course of the meetings
- 258: Various (as many as needed)
- 262: If needed (meaning TDOT is not using credits/bank)
- 263: If needed (meaning TDOT is not using credits/bank)

| ID | WBS | Task | Type | Duration | Start | Finish | Predecessors | Total slack | Free slack |
| --- | --- | --- | --- | --- | --- | --- | --- | --- | --- |
| 269 | 5.21 | **2PM5 Hold Functional Design Plans Field Review Meeting** |  | 30d | 2024-08-13 | 2024-09-24 |  | 10d |  |
| 270 | 5.21.1 | 1.0 Set Up Meeting and Develop Agenda |  | 5d | 2024-08-13 | 2024-08-19 | 271SS-10d | 357d |  |
| 271 | 5.21.2 | 2.0 Review and Complete Comment Form |  | 15d | 2024-08-27 | 2024-09-17 | 186 | 0d |  |
| 272 | 5.21.3 | 3.0 Compile Comments, Hold Meeting, and Document/Distribute Minutes |  | 5d | 2024-09-18 | 2024-09-24 | 271 | 0d |  |
| 273 | 6 | Stage 2 Complete | milestone | 0d | 2024-10-15 | 2024-10-15 | 187 | 317d |  |
| 274 | 7 | **STAGE 3- PLAN-IN-HAND** |  | 471d? | 2024-01-02 | 2025-11-19 |  | 45d |  |
| 275 | 7.1 | **3RD1 Complete Plan-in-Hand Design** |  | 95d? | 2024-08-27 | 2025-01-15 |  | 35d |  |
| 276 | 7.1.1 | 1.0 Develop ROW Acquisition Exhibits |  | 20d | 2024-08-27 | 2024-09-24 | 186 | 226d | 20d |
| 277 | 7.1.2 | 2.0 Finalize the TMP & Complete the Temporary Traffic Control Plans |  | 1d? | 2024-10-16 | 2024-10-16 | 187 | 196d | 0d |
| 278 | 7.1.3 | 3.0 Complete Plan-in-Hand Plans |  | 1d? | 2024-10-16 | 2024-10-16 | 187 | 0d |  |
| 279 | 7.1.4 | 4.0 Compile the Plan-in-Hand Plans and Participate in the Field Review |  | 5d | 2025-01-09 | 2025-01-15 | 278, 277, 288, 296, 306, 307, 319, 320, 321, 322, 290 | 152d | 0d |
| 280 | 7.2 | **3UT1 Perform Utility Coordination** |  | 324d | 2024-01-02 | 2025-04-21 |  | 137d | 0d |
| 281 | 7.2.1 | 1.0 Process Consultant Requests |  | 5d | 2024-01-02 | 2024-01-08 |  | 456d |  |
| 282 | 7.2.2 | 2.0 Send Utility Coordination Plans |  | 5d | 2024-06-13 | 2024-06-20 | 181 | 137d | 0d |
| 283 | 7.2.3 | 3.0 Conduct Utility Plan Review Kickoff Meeting |  | 2d | 2024-06-21 | 2024-06-24 | 282 | 341d |  |
| 284 | 7.2.4 | 4.0 60-Day Deconfliction Meeting |  | 40d | 2024-06-21 | 2024-08-16 | 282 | 303d |  |
| 285 | 7.2.5 | 5.0 Complete 120-day Utility Review and Process Relocation Contract Requests |  | 86d | 2024-06-21 | 2024-10-22 | 282 | 137d | 0d |
| 286 | 7.2.6 | 6.0 Submit Rainbows to Environmental |  | 10d | 2024-10-23 | 2024-11-05 | 285 | 236d | 0d |
| 287 | 7.2.7 | 7.0 Put Utilities to Work |  | 120d | 2024-10-23 | 2025-04-21 | 285 | 137d |  |
| 288 | 7.2.8 | 8.0 Submit Construction Drawings to Design |  | 10d | 2024-12-23 | 2025-01-08 | 285FS+40d | 152d | 0d |
| 289 | 7.3 | **3UT2 Perform Railroad Coordination** |  | 1d? | 2024-10-17 | 2024-10-17 |  | 0d |  |
| 290 | 7.3.1 | 1.0 Receive Railroad Plans and Estimates |  | 1d? | 2024-10-17 | 2024-10-17 | 278 | 0d |  |
| 291 | 7.4 | **3UT3 Prepare and Submit Utility/Railroad Certification** |  | 270d | 2024-10-18 | 2025-11-19 |  | 0d |  |
| 292 | 7.4.1 | 1.0 Receive and Process Utility Deposits |  | 20d | 2024-10-23 | 2024-11-20 | 285 | 237d | 100d |
| 293 | 7.4.2 | 2.0 Verify Utility Coordination is Complete |  | 10d | 2025-04-22 | 2025-05-05 | 280, 292 | 137d |  |
| 294 | 7.4.3 | 3.0 Finalize Railroad Agreement(s) |  | 270d | 2024-10-18 | 2025-11-19 | 290 | 0d |  |

Notes:
- 269: 4 weeks (20 working days) is default timing broken down as follows: ...
- 276: This could begin in Stage 2 (later) or early Stage 3. Consider advancing at risk if the project is under an accelerated schedule.
- 278: Duration depends on size of the project/complexity of design, and can be run parallel with survey at risk.
- 282: This could also tie to Compile Functional Design Plans at the latest (see 2RD1, task 11.0); see PDN for what to show on the plans (namely permittable features as no relocation areas)
- 286: Note that this could be the plans for PIH submittal if the u-sheet (task 8.0) are not available yet
- 288: Typically tied to the utilities b-date package and can either be 26 weeks prior to letter in 60 days after receiving the a-date package
- 289: Tied currently to Plan-in-Hand Plans, but could tie to Functional Design Plans if coordinated with Railroad
- 290: Duration needs to be coordinated with Railroad
- 294: Default duration that needs to be coordinated with Railroad

| ID | WBS | Task | Duration | Start | Finish | Predecessors | Total slack | Free slack |
| --- | --- | --- | --- | --- | --- | --- | --- | --- |
| 295 | 7.5 | **3EN1 Finalize Stream & Wetland Mitigation Design** | 30d | 2024-08-27 | 2024-10-08 |  | 212d |  |
| 296 | 7.5.1 | 1.0 Finalize Mitigation Plans | 30d | 2024-08-27 | 2024-10-08 | 186, 263 | 212d | 60d |
| 297 | 7.6 | **3EN2 Complete and Obtain Aquatic Permit** | 67d? | 2024-09-03 | 2024-12-09 |  | 236d |  |
| 298 | 7.6.1 | 1.0 Complete Aquatic Permit Application (for the roadway project) | 40d | 2024-09-03 | 2024-10-28 | 263, 235FF, 253 | 262d | 0d |
| 299 | 7.6.2 | 2.0 Obtain Aquatic Resource Permits | 1d? | 2024-10-29 | 2024-10-29 | 298 | 262d |  |
| 300 | 7.6.3 | 3.0 Modify or Complete Aquatic Permit Application (for Utility Relocation Impacts) | 20d | 2024-11-06 | 2024-12-06 | 286 | 236d | 0d |
| 301 | 7.6.4 | 4.0 Obtain Aquatic Resource Permits (for utilities) | 1d? | 2024-12-09 | 2024-12-09 | 300 | 236d |  |
| 302 | 7.7 | **4EN1 Complete and Obtain Stormwater Permit** | 60d | 2025-01-16 | 2025-04-11 |  | 152d |  |
| 303 | 7.7.1 | 1.0 Complete Stormwater Permit Application | 30d | 2025-01-16 | 2025-02-28 | 326FS-15d | 152d | 0d |
| 304 | 7.7.2 | 2.0 Obtain NPDES Coverage | 30d | 2025-03-03 | 2025-04-11 | 303 | 152d |  |
| 305 | 7.8 | **3ST1 Complete Structural Design** | 10d? | 2024-10-16 | 2024-10-29 |  | 197d |  |
| 306 | 7.8.1 | 1.0 Complete Retaining/Noise Wall Sheets | 1d? | 2024-10-29 | 2024-10-29 | 240, 222, 221, 187 | 197d | 45d |
| 307 | 7.8.2 | 2.0 Complete Design and Detail Bridge Plans and Estimate | 1d? | 2024-10-16 | 2024-10-16 | 224, 187 | 206d | 54d |
| 308 | 7.9 | **3RW1 Complete Appraisal and Initiate Acquisition** | 66d? | 2024-08-27 | 2024-12-02 |  | 206d |  |
| 309 | 7.9.1 | 1.0 Produce Preliminary Group Inspection (PGI) Report | 20d | 2024-08-27 | 2024-09-24 | 198, 199, 186 | 206d | 0d |
| 310 | 7.9.2 | 2.0 Employ Fee Appraiser | 20d | 2024-09-25 | 2024-10-22 | 309 | 206d | 0d |
| 311 | 7.9.3 | 3.0 Stake ROW | 20d | 2024-09-25 | 2024-10-22 | 309 | 206d | 0d |
| 312 | 7.9.4 | 4.0 Appraise Property | 1d? | 2024-10-23 | 2024-10-23 | 310, 276, 311 | 206d | 0d |
| 313 | 7.9.5 | 5.0 Review Appraisals | 1d? | 2024-12-02 | 2024-12-02 | 312SS+25d | 206d | 0d |
| 314 | 7.10 | **3RW2 Prepare and Submit ROW Certification** | 6d? | 2025-01-16 | 2025-01-24 |  | 206d |  |
| 315 | 7.10.1 | 1.0 Perform/Finish Acquiring Property | 1d? | 2025-01-16 | 2025-01-16 | 313SS+30d | 206d | 0d |
| 316 | 7.10.2 | 2.0 Perform/Finish ROW Relocation | 1d? | 2025-01-16 | 2025-01-16 | 313SS+30d | 206d | 0d |
| 317 | 7.10.3 | 3.0 Review ROW Acquisition Process, Verify/Update Schedule, and Issue ROW Certification | 5d | 2025-01-17 | 2025-01-24 | 315, 316 | 206d |  |
| 318 | 7.11 | **3TO1 Complete Signal, Lighting, and TSMO/ITS Device Design** | 30d | 2024-10-16 | 2024-11-29 |  | 177d |  |
| 319 | 7.11.1 | 1.0 Complete Signal Design | 30d | 2024-10-16 | 2024-11-29 | 223, 187 | 177d | 25d |
| 320 | 7.11.2 | 2.0 Complete Lighting Design | 30d | 2024-10-16 | 2024-11-29 | 223, 187 | 177d | 25d |
| 321 | 7.11.3 | 3.0 Complete TSMO/ITS Device Design | 30d | 2024-10-16 | 2024-11-29 | 223, 187 | 177d | 25d |
| 322 | 7.11.4 | 4.0 Review the TMP for Compliance | 10d | 2024-10-17 | 2024-10-30 | 277 | 196d | 44d |

Notes:
- 298: Confirm tie to certain env. tech studies or the environmental document
- 299: Duration based on permit type determined under 2EN2. This duration could be 120 days to 18 months depending on what permit is needed and if a off-site mitigation site is needed....
- 300: Note the tie to receiving response from utility owners regarding relocation of their facilities. This is a late tie, notably if the relocation is going to impact a feature. This tie may drive a lag in the schedule that can be mitigated with early utility coordination and a clear depiction of where the utility cannot go on the Utility Coordination Plans (or Functional Design Plans).
- 301: Work with Permitting on mitigating this risk, which could considerably extend the schedule depending on utility impacts to features. This risk can be mitigated with early coordination and working with utilities to understand where they can and cannot move.
- 303: As soon as the ESCPs are available; application must include stamped cover sheet
- 309: This can tie to Line and Grade if Line and Grade includes survey of the ROW.
- 312: Duration will depend on number of acquisitions/relocations
- 313: Duration will depend on number of acquisitions/relocations
- 315: Duration will depend on number of acquisitions/relocations
- 316: Duration will depend on number of acquisitions/relocations

| ID | WBS | Task | Type | Duration | Start | Finish | Predecessors | Total slack | Free slack |
| --- | --- | --- | --- | --- | --- | --- | --- | --- | --- |
| 323 | 7.12 | **3PM2 Hold Plan-in-Hand Field Review Meeting** |  | 25d | 2025-01-02 | 2025-02-06 |  | 162d |  |
| 324 | 7.12.1 | 1.0 Set Up Meeting and Develop Agenda |  | 5d | 2025-01-02 | 2025-01-08 | 325SS-10d | 262d |  |
| 325 | 7.12.2 | 2.0 Review and Complete Comment Form |  | 10d | 2025-01-16 | 2025-01-30 | 279 | 152d | 0d |
| 326 | 7.12.3 | 3.0 Compile Comments, Hold Meeting, and Document/Distribute Minutes |  | 5d | 2025-01-31 | 2025-02-06 | 325 | 152d | 0d |
| 327 | 8 | Stage 3 Complete | milestone | 0d | 2025-02-06 | 2025-02-06 | 326 | 242d |  |
| 328 | 9 | **STAGE 4- PS&E** |  | 35d | 2025-02-07 | 2025-03-28 |  | 162d |  |
| 329 | 9.1 | **4RD1 Finalize Construction Documents** |  | 25d | 2025-02-07 | 2025-03-14 |  | 162d |  |
| 330 | 9.1.1 | 1.0 Finalize the Roadway Plans for the PS&E Review Meeting |  | 15d | 2025-02-07 | 2025-02-28 | 326 | 162d | 0d |
| 331 | 9.1.2 | 2.0 Compile the Final Construction Documents |  | 10d | 2025-03-03 | 2025-03-14 | 330, 333, 334, 339, 340, 336, 337 | 162d | 0d |
| 332 | 9.2 | **4GT1 Finalize Geotech Plans** |  | 15d | 2025-02-07 | 2025-02-28 |  | 162d |  |
| 333 | 9.2.1 | 1.0 Finalize Geotechnical Design Documents |  | 15d | 2025-02-07 | 2025-02-28 | 326 | 162d | 0d |
| 334 | 9.2.2 | 2.0 Finalize Geotechnical Special Provisions for Letting |  | 15d | 2025-02-07 | 2025-02-28 | 326 | 162d | 0d |
| 335 | 9.3 | **4ST1 Finalize Structural Plans** |  | 15d | 2025-02-07 | 2025-02-28 |  | 162d |  |
| 336 | 9.3.1 | 1.0 Finalize Retaining/Noise Wall Plans |  | 15d | 2025-02-07 | 2025-02-28 | 326 | 162d | 0d |
| 337 | 9.3.2 | 2.0 Finalize Bridge Plans |  | 15d | 2025-02-07 | 2025-02-28 | 326 | 162d | 0d |
| 338 | 9.4 | **4TO1 Finalize Signal, Lighting, and TSMO/ITS Plans** |  | 15d | 2025-02-07 | 2025-02-28 |  | 162d |  |
| 339 | 9.4.1 | 1.0 Finalize Signals, Lighting, and TSMO/ITS Design Documents |  | 15d | 2025-02-07 | 2025-02-28 | 326 | 162d | 0d |
| 340 | 9.4.2 | 2.0 Finalize ITS Special Provisions |  | 15d | 2025-02-07 | 2025-02-28 | 326 | 162d | 0d |
| 341 | 9.5 | **4PM2 Hold PS&E Review Meeting** |  | 20d | 2025-03-03 | 2025-03-28 |  | 172d |  |
| 342 | 9.5.1 | 1.0 Set Up Meeting and Develop Agenda |  | 5d | 2025-03-03 | 2025-03-07 | 343SS-10d | 222d |  |
| 343 | 9.5.2 | 2.0 Review and Complete Comment Form |  | 5d | 2025-03-17 | 2025-03-21 | 331 | 162d | 0d |
| 344 | 9.5.3 | 3.0 Compile Comments, Hold Meeting, and Finalize Project Documentation |  | 5d | 2025-03-24 | 2025-03-28 | 343 | 162d |  |
| 345 | 10 | Construction Document Turn-in | milestone | 5d | 2025-11-20 | 2025-11-26 | 297, 244, 204, 293, 294, 317, 344, 249, 155, 304 | 0d |  |
| 346 | 11 | Stage 4 Complete | milestone | 0d | 2025-11-26 | 2025-11-26 | 345 | 40d |  |
| 347 | 12 | Project Letting | milestone | 40d | 2025-12-01 | 2026-01-29 | 345 | 0d |  |

Notes:
- 323: 3 weeks (15 working days) is default timing broken down as follows: / 1) 2 weeks for TDOT reviewers to complete their review and submit a completed Comment Resolution Form / 2) One week for design team to compile comments and prepare for meeting. / 3) Field review meeting to occur at the end of the 3 weeks/15 working days.
- 341: 2 weeks (10 working days) is default timing broken down as follows: / 1) 1 week for TDOT reviewers to complete their review and submit a completed Comment Resolution Form / 2) One week for design team to compile comments and prepare for meeting. / 3) Last review meeting to occur at the end of the 2 weeks/10 working days.
